# BB-11 - ubouw hoogbouwskelet

Schedule from MS Project, 2003-01-12 to 2003-01-26, status date 2003-01-08.
BAM Nelissen Van Egteren

## Calendars

- ALLEEN WERKDAGEN: Mon-Fri 08:30-12:30, 13:00-17:00; Sat-Sun off. Exceptions (off unless hours are given): 2003-01-11 to 2003-01-12 08:30-12:30, 13:00-17:00, 2003-01-18 to 2003-01-19 08:30-12:30, 13:00-17:00, 2003-01-25 to 2003-01-26 08:30-12:30, 13:00-17:00.

## Schedule

| ID | WBS | Task | Type | Duration | Start | Finish | Predecessors | Total slack |
| --- | --- | --- | --- | --- | --- | --- | --- | --- |
| 1 | 1 | **BOVENBOUWFASE** |  | 15d | 2003-01-12 | 2003-01-26 |  | 0d |
| 2 | 1.1 | beg.grond betonkolommen maken |  | 5d | 2003-01-12 | 2003-01-16 |  | 0d |
| 3 | 1.2 | beg.grond betonwanden maken |  | 5d | 2003-01-12 | 2003-01-16 | 2SS | 0d |
| 4 | 1.3 | 1e verd.vloer bekisting/breedplaat |  | 5d | 2003-01-17 | 2003-01-21 | 3SS+5d | 0d |
| 5 | 1.4 | 1e verd.vloer wapening |  | 5d | 2003-01-21 | 2003-01-25 | 4SS+4d | 0d |
| 6 | 1.5 | 1e verd.vloer beton storten |  | 1d | 2003-01-26 | 2003-01-26 | 5SS+5d | 0d |
| 7 | 1.6 | start productietijd skelet | milestone | 0d | 2003-01-26 | 2003-01-26 | 6SS+1d | 0d |
